# RIO LACRAMARCA-TRAMOS PENDIENTES A1/A2T1 - Rev02

Schedule from Primavera P6, 2025-07-01 to 2025-09-23, data date 2025-07-01, costs in SOL.

## Calendars

- Calendario Actuaciones 8xdia: Mon-Sun 08:00-12:00, 13:00-17:00.

## Resources

| Resource | Group | Unit | Rate |
| --- | --- | --- | --- |
| COSTO - CONSORCIO | equipment |  | 1 |
| MOTONIVELADORA 185HP - CONSORCIO | equipment |  | 48.75 |
| CAMION CISTERNA (5,000 GLNS.) - CONSORCIO | equipment |  | 36.25 |
| RODILLO LISO VIBRATORIO AUTOPROPULSADO 135HP - CONSORCIO | equipment |  | 209.15 |
| PEON VIGIA - CONSORCIO | labor |  | 20.34 |
| OFICIAL - CONSORCIO | labor |  |  |
| MATERIALES (VARIOS) - CONSORCIO | material |  | 15 |
| HERRAMIENTAS MANUALES - CONSORCIO | equipment |  | 202.97 |
| CAPATAZ - CONSORCIO | labor |  |  |
| PEON - CONSORCIO | labor |  |  |
| TRACTOR DE ORUGAS CAT D6D - CONSORCIO | equipment |  | 60.06 |
| EXCAVADORA CAT 336 - CONSORCIO | equipment |  | 56.29 |
| MOTOBOMBA DE 8" (34HP) - CONSORCIO | equipment |  | 130 |
| GEOTEXTIL - CONSORCIO | material |  | 9.7 |
| CAMION GRUA 20 TON - CONSORCIO | equipment |  | 229 |
| RETROEXCAVADORA SOBRE LLANTAS 58 HP 1 yd3 - CONSORCIO | equipment |  |  |
| OPERARIO - CONSORCIO | labor |  |  |
| RODILLO LISO VIBRATORIO AUTOPROPULSADO 101-135 HP 10-12 tn - CONSORCIO | equipment |  |  |
| COMPACTADORA VIBRATORIA TIPO PLANCHA 7 HP - CONSORCIO | equipment |  | 5.75 |
| MEZCLADORA DE CONCRETO 11 P3 (23 HP) - CONSORCIO | equipment |  |  |
| VIBRADOR DE CONCRETO 4 HP 1.25" - CONSORCIO | equipment |  |  |
| CEMENTO PORTLAND TIPO I (42.5 kg) - CONSORCIO | material | Bls | 26.5 |
| ARENA - CONSORCIO | material | m3 | 38.45 |
| PIEDRA CHANCADA 1/2" (PUESTO EN OBRA) - CONSORCIO | material | m3 | 55 |
| MADERA TORNILLO - CONSORCIO | material | p2 | 8.5 |
| AGUA - CONSORCIO | material | m3 | 8 |
| ALAMBRE NEGRO # 8 - Lacramaca A1/A2T1 | material | kg | 6.35 |
| ACERO CORRUGADO fy=4200 kg/cm2 GRADO 60 - CONSORCIO | material | kg | 4.62 |
| CAMION VOLQUETE DE 15 m3 - CONSORCIO | equipment |  | 32.5 |
| Tubería HDPE Corrugado de 800 mm - CONSORCIO | material | m | 940.5 |
| CARGADOR SOBRE LLANTAS DE 250HP 4yd3 - CONSORCIO | equipment |  | 390 |
| TOPOGRAFO - CONSORCIO | labor |  |  |
| YESO SACO 40KG - CONSORCIO | material | Und |  |
| ESTACAS DE MADERA - CONSORCIO | material | Und |  |
| PINTURA ESMALTE - CONSORCIO | material |  |  |
| GPS - CONSORCIO | equipment |  |  |
| ESTACION TOTAL INC. ACCESORIOS - CONSORCIO | equipment |  |  |
| NIVEL ELECTRONICO - CONSORCIO | equipment |  |  |
| CLAVOS C/CABEZA PARA MADERA (PROMEDIO) - CONSORCIO | material | kg | 6.2 |
| DESMOLDANTE PARA MADERA - CONSORCIO | material | Galon | 98.5 |
| PEON-VIGIA - CONSORCIO | labor |  | 20.34 |

## Schedule

| ID | WBS | Activity | Type | Duration | Start | Finish | Predecessors | Total float | Free float | Resources | Cost |
| --- | --- | --- | --- | --- | --- | --- | --- | --- | --- | --- | --- |
|  | 000 | **GENERALES** |  |  | 2025-07-01 | 2025-09-23 |  |  |  |  |  |
|  | 0 | **HITOS CONTRACTUALES** |  |  | 2025-07-01 | 2025-09-23 |  |  |  |  |  |
| HITO_KOM |  | Kick of meeting | milestone | 0d | 2025-07-01 | 2025-07-01 |  | 0d |  |  |  |
| HITO_ACCESO_AL_SITIO |  | Inicio de Plazo contractual - Acceso al sitio | milestone | 0d | 2025-07-17 | 2025-07-17 | HITO_KOM SS+16d | 59d | 0d |  |  |
| HITO_INICIO_EXC |  | Inicio de Excavación | milestone | 0d | 2025-07-22 | 2025-07-22 | HITO_ACCESO_AL_SITIO SS+5d | 64d |  |  |  |
| HITO_INICIO_RELLENO |  | Inicio de Relleno de Dique | milestone | 0d | 2025-08-02 | 2025-08-02 | HITO_ACCESO_AL_SITIO SS+10d, HITO_PLAN_RELLENO SS | 53d |  |  |  |
| HITO_FIN_PROY |  | Fin de Plazo Contractual - Culminación de Obra | milestone | 0d | 2025-09-23 | 2025-09-23 | HITO_PLAN_FIN_OBRA FF | 0d |  |  |  |
|  | 1 | **HITOS PLANIFICADOS** |  |  | 2025-07-17 | 2025-09-23 |  |  |  |  |  |
| HITO_PLAN_ACC |  | Acceso al Sitio - Inicio de Trabajos | milestone | 0d | 2025-07-17 | 2025-07-17 | HITO_KOM SS+16d | 0d |  |  |  |
| HITO_PLAN_EXC |  | Inicio de Excavaciones | milestone | 0d | 2025-07-22 | 2025-07-22 | A1-D-01_EXC SS, A2-I-02_EXC SS | 64d |  |  |  |
| HITO_PLAN_RELLENO |  | Inicio de Rellenos | milestone | 0d | 2025-08-02 | 2025-08-02 | A2-I-02_CONFD SS | 53d | 0d |  |  |
| HITO_PLAN_FIN_OBRA |  | Fin de Obra PLANIFICADA | milestone | 0d | 2025-09-23 | 2025-09-23 | HITO_PLAN_ACC SS, DESMOV FF, HITO_PLAN_EXC SF | 0d |  |  |  |
|  | 501 | **DEFENSAS RIBEREÑAS** |  |  | 2025-07-17 | 2025-09-23 |  |  |  |  |  |
|  | C | **CONSTRUCCIÓN** |  |  | 2025-07-17 | 2025-09-23 |  |  |  |  |  |
|  | 90 | **TRABAJOS PRELIMINARES** |  |  | 2025-07-17 | 2025-09-23 |  |  |  |  |  |
|  | 02 | **COSTOS DEL CONTRATISTA PRINCIPAL** |  |  | 2025-07-17 | 2025-09-23 |  |  |  |  |  |
|  | 03 | **SUBPROYECTO A-1** |  |  | 2025-07-17 | 2025-09-23 |  |  |  |  |  |
|  | 3 | **OBRAS PRELIMINARES (A-1)** |  |  | 2025-07-20 | 2025-09-23 |  |  |  |  |  |
| OBP-INST-A1 |  | A1: INSTALACIONES PROVISIONALES PARA LA OBRA |  | 5d | 2025-07-20 | 2025-07-24 | MOV-01-A1 | 56d |  | COSTO - CONSORCIO [157 h] | 80,975 |
| OBP-MANTVIAL-A1 |  | A1: MANTENIMIENTO DE TRÁNSITO Y SEGURIDAD VIAL | level of effort | 66d | 2025-07-20 | 2025-09-23 | MOV-01-A1 | 0d |  | MOTONIVELADORA 185HP - CONSORCIO [90 h]; CAMION CISTERNA (5,000 GLNS.) - CONSORCIO [288 h]; RODILLO LISO VIBRATORIO AUTOPROPULSADO 135HP - CONSORCIO [180 h]; PEON VIGIA - CONSORCIO [720 h]; OFICIAL - CONSORCIO [360 h]; MATERIALES (VARIOS) - CONSORCIO [1.5]; HERRAMIENTAS MANUALES - CONSORCIO [0.05 h] | 187,755.04 |
|  | 1 | **TRABAJOS PRELIMINARES (A-1)** |  |  | 2025-07-17 | 2025-09-23 |  |  |  |  |  |
| MOV-01-A1 |  | A1: MOVILIZACION 01 (A1) |  | 3d | 2025-07-17 | 2025-07-19 | HITO_PLAN_ACC SS | 0d |  | COSTO - CONSORCIO [5 h] | 46,082.5 |
| SSO-A1 |  | A1: SEGURIDAD Y SALUD OCUPACIONAL | level of effort | 69d | 2025-07-17 | 2025-09-23 | HITO_PLAN_ACC SS | 0d |  | COSTO - CONSORCIO | 128,512.5 |
| TP-TOPO-A1 |  | A1: TOPOGRAFÍA Y GEOREFERENCIACIÓN | level of effort | 64d | 2025-07-17 | 2025-09-18 | HITO_PLAN_ACC SS | 0d |  | PEON - CONSORCIO [1440 h]; TOPOGRAFO - CONSORCIO [360 h]; ACERO CORRUGADO fy=4200 kg/cm2 GRADO 60 - CONSORCIO [40.5 kg]; CEMENTO PORTLAND TIPO I (42.5 kg) - CONSORCIO [2.25 Bls]; YESO SACO 40KG - CONSORCIO [2.25 Und]; ESTACAS DE MADERA - CONSORCIO [105 Und]; PINTURA ESMALTE - CONSORCIO [4.5]; GPS - CONSORCIO [360 h]; ESTACION TOTAL INC. ACCESORIOS - CONSORCIO [720 h]; NIVEL ELECTRONICO - CONSORCIO [720 h]; HERRAMIENTAS MANUALES - CONSORCIO [0.05 h] | 73,704.6 |
| MOV-02-A1 |  | A1: MOVILIZACION 02 (A1) |  | 2d | 2025-07-20 | 2025-07-21 | MOV-01-A1 | 41d | 0d | COSTO - CONSORCIO [540 h] | 46,082.5 |

| ID | WBS | Activity | Type | Duration | Start | Finish | Predecessors | Total float | Free float | Resources | Cost |
| --- | --- | --- | --- | --- | --- | --- | --- | --- | --- | --- | --- |
|  | 1 | **SUBPROYECTO A2T1** |  |  | 2025-07-17 | 2025-09-18 |  |  |  |  |  |
|  | 3 | **OBRAS PRELIMINARES (A2T1)** |  |  | 2025-07-22 | 2025-09-18 |  |  |  |  |  |
| OBP-INST-A2T1 |  | A2T1: INSTALACIONES PROVISIONALES PARA LA OBRA |  | 5d | 2025-07-22 | 2025-07-26 | MOV-01-A2T1 | 54d |  | COSTO - CONSORCIO [1 h] | 73,620 |
| OBP-MANTVIAL-A2T1 |  | A2T1: MANTENIMIENTO DE TRÁNSITO Y SEGURIDAD VIAL | level of effort | 59d | 2025-07-22 | 2025-09-18 | MOV-01-A2T1 | 0d |  | MOTONIVELADORA 185HP - CONSORCIO; CAMION CISTERNA (5,000 GLNS.) - CONSORCIO; RODILLO LISO VIBRATORIO AUTOPROPULSADO 135HP - CONSORCIO; OFICIAL - CONSORCIO; PEON VIGIA - CONSORCIO; MATERIALES (VARIOS) - CONSORCIO; HERRAMIENTAS MANUALES - CONSORCIO | 187,755.04 |
|  | 1 | **TRABAJOS PRELIMINARES (A2T1)** |  |  | 2025-07-17 | 2025-08-25 |  |  |  |  |  |
| MOV-01-A2T1 |  | A2T1: MOVILIZACION (A2T1) |  | 5d | 2025-07-17 | 2025-07-21 | HITO_PLAN_ACC SS | 20d | 0d | COSTO - CONSORCIO [1 h] | 46,082.5 |
| SSO-A2T1 |  | A2T1: SEGURIDAD Y SALUD OCUPACIONAL | level of effort | 40d | 2025-07-17 | 2025-08-25 | HITO_PLAN_ACC SS | 20d | 0d | COSTO - CONSORCIO [1 h] | 128,512.5 |
| TP-TOPO-A2T1 |  | A2T1: TOPOGRAFÍA Y GEOREFERENCIACIÓN | level of effort | 40d | 2025-07-17 | 2025-08-25 | HITO_PLAN_ACC SS | 20d | 0d | GPS - CONSORCIO [360 h]; PEON - CONSORCIO [1440 h]; TOPOGRAFO - CONSORCIO [360 h]; ACERO CORRUGADO fy=4200 kg/cm2 GRADO 60 - CONSORCIO [40.5 kg]; CEMENTO PORTLAND TIPO I (42.5 kg) - CONSORCIO [2.25 Bls]; YESO SACO 40KG - CONSORCIO [2.25 Und]; ESTACAS DE MADERA - CONSORCIO [105 Und]; PINTURA ESMALTE - CONSORCIO [4.5]; ESTACION TOTAL INC. ACCESORIOS - CONSORCIO [720 h]; NIVEL ELECTRONICO - CONSORCIO [720 h]; HERRAMIENTAS MANUALES - CONSORCIO [0.05 h] | 73,704.6 |
|  | 80 | **FACILIDADES DE OBRA** |  |  | 2025-07-20 | 2025-07-29 |  |  |  |  |  |
|  | 04 | **OBRAS DE DESVIO TEMPORAL** |  |  | 2025-07-20 | 2025-07-29 |  |  |  |  |  |
|  | 03 | **SUBPROYECTO A-1** |  |  | 2025-07-20 | 2025-07-29 |  |  |  |  |  |
|  | 03 | **DESCOLMATACIÓN DE CAUCE (A-1)** |  |  | 2025-07-20 | 2025-07-29 |  |  |  |  |  |
| DEBROC-A1 |  | A1: DESBROCE Y LIMPIEZA EN ZONA NO BOSCOSA |  | 10d | 2025-07-20 | 2025-07-29 | MOV-01-A1 | 0d |  | CAPATAZ - CONSORCIO [5.16 h]; PEON - CONSORCIO [154.66 h]; CAMION VOLQUETE DE 15 m3 - CONSORCIO [51.55 h]; HERRAMIENTAS MANUALES - CONSORCIO [338.31 h]; EXCAVADORA CAT 336 - CONSORCIO [12.89 h]; TRACTOR DE ORUGAS CAT D6D - CONSORCIO [25.78 h] | 35,025.75 |
| DESCOL-A1 |  | A1: DESCOLMATACIÓN DE CAUCE NATURAL DEL RÍO LACRAMARCA |  | 3d | 2025-07-20 | 2025-07-22 | DEBROC-A1 SS, MOV-01-A1 | 0d |  | CAPATAZ - CONSORCIO [5.78 h]; PEON - CONSORCIO [46.21 h]; TRACTOR DE ORUGAS CAT D6D - CONSORCIO [23.1 h]; HERRAMIENTAS MANUALES - CONSORCIO [51.98 h] | 12,285.67 |
| DESV-RIO-A1 |  | A1: CONFORMACIÓN DE DESVIO EN CAUCE DE RÍO |  | 5d | 2025-07-20 | 2025-07-24 | DESCOL-A1 SS | 0d |  | CAPATAZ - CONSORCIO [17.54 h]; PEON - CONSORCIO [35.08 h]; EXCAVADORA CAT 336 - CONSORCIO [8.77 h]; TRACTOR DE ORUGAS CAT D6D - CONSORCIO [35.08 h]; HERRAMIENTAS MANUALES - CONSORCIO [71.04 h] | 22,198.67 |
|  | 1 | **SUBPROYECTO A2T1** |  |  | 2025-07-22 | 2025-07-26 |  |  |  |  |  |
|  | 03 | **DESCOLMATACIÓN DE CAUCE Y OBRAS AUXILIARES (A2T1)** |  |  | 2025-07-22 | 2025-07-26 |  |  |  |  |  |
| DEBROC-A2T1 |  | A2T1: DESBROCE Y LIMPIEZA EN ZONA NO BOSCOSA |  | 5d | 2025-07-22 | 2025-07-26 | MOV-01-A2T1 | 20d | 0d | CAPATAZ - CONSORCIO [2.62 h]; PEON - CONSORCIO [78.64 h]; HERRAMIENTAS MANUALES - CONSORCIO [86.01 h]; CAMION VOLQUETE DE 15 m3 - CONSORCIO [13.11 h]; TRACTOR DE ORUGAS CAT D6D - CONSORCIO [9.83 h]; EXCAVADORA CAT 336 - CONSORCIO [6.55 h] | 17,809.64 |
| DESCOL-A2T1 |  | A2T1: DESCOLMATACIÓN DE CAUCE NATURAL DEL RÍO LACRAMARCA |  | 2d | 2025-07-22 | 2025-07-23 | DEBROC-A2T1 SS | 20d | 0d | CAPATAZ - CONSORCIO [3.8 h]; PEON - CONSORCIO [30.39 h]; TRACTOR DE ORUGAS CAT D6D - CONSORCIO [15.2 h]; HERRAMIENTAS MANUALES - CONSORCIO [34.19 h] | 8,080.84 |
| DESV-RIO-A2T1 |  | A2T1: CONFORMACIÓN DE DESVIO EN CAUCE DE RÍO |  | 2d | 2025-07-22 | 2025-07-23 | DESCOL-A2T1 SS, DESCOL-A2T1 FF | 20d | 0d | CAPATAZ - CONSORCIO [6.93 h]; PEON - CONSORCIO [13.85 h]; EXCAVADORA CAT 336 - CONSORCIO [3.46 h]; TRACTOR DE ORUGAS CAT D6D - CONSORCIO [13.85 h]; HERRAMIENTAS MANUALES - CONSORCIO [28.05 h] | 8,764.97 |
| RELLE-NO-EST-A2T1 |  | A2T1: RELLENO NO ESTRUCTURAL CON MATERIAL PROPIO |  | 2d | 2025-07-24 | 2025-07-25 | DESV-RIO-A2T1 | 55d |  | CAPATAZ - CONSORCIO [6.48 h]; OFICIAL - CONSORCIO [12.95 h]; PEON - CONSORCIO [12.95 h]; TRACTOR DE ORUGAS CAT D6D - CONSORCIO [12.95 h]; HERRAMIENTAS MANUALES - CONSORCIO [38.85 h] | 7,029.79 |
|  | 70 | **OBRAS EXTERIORES** |  |  | 2025-07-22 | 2025-09-23 |  |  |  |  |  |
|  | 08 | **OBRAS DE EDIFICACIONES MENORES** |  |  | 2025-07-22 | 2025-08-08 |  |  |  |  |  |
|  | 03 | **SUBPROYECTO A1** |  |  | 2025-07-22 | 2025-08-08 |  |  |  |  |  |
|  | 01 | **OBRAS DE ARTE** |  |  | 2025-07-22 | 2025-08-08 |  |  |  |  |  |
|  | 1 | **ESTRUCTURAS DE REBOSE (Subproyecto A1)** |  |  | 2025-07-22 | 2025-08-08 |  |  |  |  |  |
|  | 1 | **MOVIMIENTO DE TIERRAS** |  |  | 2025-07-22 | 2025-08-08 |  |  |  |  |  |
| OA-DESBR-A1 |  | A1: DESBROCE Y LIMPIEZA |  | 2d | 2025-07-22 | 2025-07-23 | TP-TOPO-A1, MOV-02-A1 | 41d | 0d | CAPATAZ - CONSORCIO [0.54 h]; PEON - CONSORCIO [21.51 h]; HERRAMIENTAS MANUALES - CONSORCIO [1.82 h]; MOTONIVELADORA 185HP - CONSORCIO [2.69 h]; TRACTOR DE ORUGAS CAT D6D - CONSORCIO [2.69 h] | 2,811.96 |
| OA-EXC-A1 |  | A1: EXCAVACION ESTRUCTURAL BAJO AGUA (EXCAVACION ESTRUCTURAL PARA OBRAS DE ARTE) |  | 5d | 2025-07-22 | 2025-07-26 | OA-DESBR-A1 FF, OA-DESBR-A1 SS | 41d | 0d | CAPATAZ - CONSORCIO [8.26 h]; PEON - CONSORCIO [41.28 h]; RETROEXCAVADORA SOBRE LLANTAS 58 HP 1 yd3 - CONSORCIO [41.28 h]; MOTOBOMBA DE 8" (34HP) - CONSORCIO [41.28 h]; HERRAMIENTAS MANUALES - CONSORCIO [12.38 h] | 14,618.81 |
| OA-CA-A1 |  | A1: CAMA DE ARENA |  | 1d | 2025-07-27 | 2025-07-27 | OA-EXC-A1 | 41d | 0d | CAPATAZ - CONSORCIO [0.58 h]; OFICIAL - CONSORCIO [5.77 h]; PEON - CONSORCIO [5.77 h]; RETROEXCAVADORA SOBRE LLANTAS 58 HP 1 yd3 - CONSORCIO [0.29 h]; COMPACTADORA VIBRATORIA TIPO PLANCHA 7 HP - CONSORCIO [2.89 h]; CAMION VOLQUETE DE 15 m3 - CONSORCIO [0.31 h]; CAMION CISTERNA (5,000 GLNS.) - CONSORCIO [2.89 h]; ARENA - CONSORCIO [17.32 m3]; HERRAMIENTAS MANUALES - CONSORCIO [43.29 h] | 2,046.35 |
| OA-RELL-A1 |  | A1: RELLENO ESTRUCTURAL PARA OBRAS DE ARTE CON MATERIAL DE PRESTAMO |  | 4d | 2025-08-05 | 2025-08-08 | OA-ENCOF-A1 | 41d |  | CAPATAZ - CONSORCIO [5.25 h]; OPERARIO - CONSORCIO [74.06 h]; PEON - CONSORCIO [52.49 h]; RETROEXCAVADORA SOBRE LLANTAS 58 HP 1 yd3 - CONSORCIO [13.12 h]; RODILLO LISO VIBRATORIO AUTOPROPULSADO 101-135 HP 10-12 tn - CONSORCIO [52.49 h]; COMPACTADORA VIBRATORIA TIPO PLANCHA 7 HP - CONSORCIO [52.49 h]; CAMION CISTERNA (5,000 GLNS.) - CONSORCIO [26.24 h]; HERRAMIENTAS MANUALES - CONSORCIO [8.27 h] | 26,410.18 |

| ID | WBS | Activity | Duration | Start | Finish | Predecessors | Total float | Free float | Resources | Cost | OHLA-DAT | OHLA-REND | OHLA-DUR | OHLA_ESTRUCTURA OFERTA_A2-T1 | OHLA Diques | Unidad |
| --- | --- | --- | --- | --- | --- | --- | --- | --- | --- | --- | --- | --- | --- | --- | --- | --- |
|  | 2 | **OBRAS DE CONCRETO** |  | 2025-07-28 | 2025-08-04 |  |  |  |  |  |  |  |  |  |  |  |
| OA-CONC100-A1 |  | A1: CONCRETO f'c=100 kg/cm2 | 1d | 2025-07-28 | 2025-07-28 | OA-EXC-A1, OA-CA-A1 | 41d | 0d | OPERARIO - CONSORCIO [5.01 h]; OFICIAL - CONSORCIO [5.01 h]; PEON - CONSORCIO [25.03 h]; MEZCLADORA DE CONCRETO 11 P3 (23 HP) - CONSORCIO [2.5 h]; VIBRADOR DE CONCRETO 4 HP 1.25" - CONSORCIO [2.5 h]; CEMENTO PORTLAND TIPO I (42.5 kg) - CONSORCIO [26.28 Bls]; ARENA - CONSORCIO [2.85 m3]; PIEDRA CHANCADA 1/2" (PUESTO EN OBRA) - CONSORCIO [2.85 m3]; MADERA TORNILLO - CONSORCIO [18.4 p2]; AGUA - CONSORCIO [0.96 m3]; HERRAMIENTAS MANUALES - CONSORCIO [0.13 h] | 2,008.54 |  |  |  |  |  |  |
| OA-ACERO-A1 |  | A1: ACERO DE REFUERZO fy=4200 kg/cm2 | 4d | 2025-07-29 | 2025-08-01 | OA-CONC100-A1 | 41d | 0d | CAPATAZ - CONSORCIO [10.72 h]; OPERARIO - CONSORCIO [107.23 h]; OFICIAL - CONSORCIO [107.23 h]; PEON - CONSORCIO [53.62 h]; ALAMBRE NEGRO # 8 - Lacramaca A1/A2T1 [235.91 kg]; HERRAMIENTAS MANUALES - CONSORCIO [88.47 h]; ACERO CORRUGADO fy=4200 kg/cm2 GRADO 60 - CONSORCIO [3096.3 kg] | 22,909.07 |  |  |  |  |  |  |
| OA-ENCOF-A1 |  | A1: ENCOFRADO Y DESENCOFRADO RECTO | 7d | 2025-07-29 | 2025-08-04 | OA-CONC100-A1, OA-ACERO-A1 SS | 41d | 0d | CAPATAZ - CONSORCIO [15.15 h]; OPERARIO - CONSORCIO [151.53 h]; OFICIAL - CONSORCIO [151.53 h]; PEON - CONSORCIO [75.76 h]; CAMION GRUA 20 TON - CONSORCIO [7.58 h]; MADERA TORNILLO - CONSORCIO [852.35 p2]; ALAMBRE NEGRO # 8 - Lacramaca A1/A2T1 [18.94 kg]; HERRAMIENTAS MANUALES - CONSORCIO [5.68 h]; CLAVOS C/CABEZA PARA MADERA (PROMEDIO) - CONSORCIO [37.88 kg]; DESMOLDANTE PARA MADERA - CONSORCIO [9.47 Galon] | 20,310.35 |  |  |  |  |  |  |
| OA-CONC280-A1 |  | A1: CONCRETO f'c=280 kg/cm2 | 2d | 2025-08-02 | 2025-08-03 | OA-ACERO-A1, OA-ENCOF-A1 SS | 46d |  | OPERARIO - CONSORCIO [47.97 h]; OFICIAL - CONSORCIO [47.97 h]; PEON - CONSORCIO [239.87 h]; MEZCLADORA DE CONCRETO 11 P3 (23 HP) - CONSORCIO [23.99 h]; VIBRADOR DE CONCRETO 4 HP 1.25" - CONSORCIO [23.99 h]; CEMENTO PORTLAND TIPO I (42.5 kg) - CONSORCIO [503.72 Bls]; ARENA - CONSORCIO [37.78 m3]; PIEDRA CHANCADA 1/2" (PUESTO EN OBRA) - CONSORCIO [35.26 m3]; AGUA - CONSORCIO [7.74 m3]; ALAMBRE NEGRO # 8 - Lacramaca A1/A2T1 [8.99 kg]; HERRAMIENTAS MANUALES - CONSORCIO [1.08 h] | 25,312.26 |  |  |  |  |  |  |
|  | 7 | **TUBERIAS** |  | 2025-07-31 | 2025-08-01 |  |  |  |  |  |  |  |  |  |  |  |
| OA-HDP-A1 |  | A1: SUMINISTRO E INSTALACIÓN DE TUBERÍA HDPE DN800 mm | 2d | 2025-07-31 | 2025-08-01 | OA-ACERO-A1 FF, OA-ENCOF-A1 SS | 48d |  | PEON - CONSORCIO [42.49 h]; EXCAVADORA CAT 336 - CONSORCIO [5.31 h]; Tubería HDPE Corrugado de 800 mm - CONSORCIO [25.1 m]; HERRAMIENTAS MANUALES - CONSORCIO [1 h]; OPERARIO - CONSORCIO [21.24 h]; CAPATAZ - CONSORCIO [5.31 h]; CAMION GRUA 20 TON - CONSORCIO [5.31 h] | 36,691.96 |  |  |  |  |  |  |
|  | 10 | **CUERPOS DE TERRAPLEN** |  | 2025-07-22 | 2025-09-23 |  |  |  |  |  |  |  |  |  |  |  |
|  | 02 | **DIQUES DE TIERRA COMPACTADA CON ENROCADO** |  | 2025-07-22 | 2025-09-23 |  |  |  |  |  |  |  |  |  |  |  |
|  | 2 | **DIQUES DE TIERRA COMPACTADA CON ENROCADO - SUBPROYECTO A-1** |  | 2025-07-22 | 2025-09-20 |  |  |  |  |  |  |  |  |  |  |  |
|  | 2 | **A1: DIQUE DE TIERRA COMPACTADA A1-D-01** |  | 2025-07-22 | 2025-08-19 |  |  |  |  |  |  |  |  |  |  |  |
| A1-D-01_EXC |  | A1: EXCAVACIÓN EN TERRENO NATURAL CON EQUIPO | 13d | 2025-07-22 | 2025-08-03 | MOV-01-A1, TP-TOPO-A1, DESV-RIO-A1 SS+2d, DEBROC-A1 FF | 0d |  | CAPATAZ - CONSORCIO [106.23 h]; PEON - CONSORCIO [212.46 h]; EXCAVADORA CAT 336 - CONSORCIO [212.46 h]; TRACTOR DE ORUGAS CAT D6D - CONSORCIO [106.23 h]; HERRAMIENTAS MANUALES - CONSORCIO [557.71 h] | 155,147.85 |  |  |  |  |  |  |
| A1-D-01_EXUÑ |  | A1: EXCAVACIÓN DE UÑA CON EQUIPO | 3d | 2025-08-01 | 2025-08-03 | A1-D-01_EXC FF, A1-D-01_EXC SS | 0d |  | CAPATAZ - CONSORCIO [3.93 h]; PEON - CONSORCIO [19.63 h]; MOTOBOMBA DE 8" (34HP) - CONSORCIO [19.63 h]; EXCAVADORA CAT 336 - CONSORCIO [19.63 h]; HERRAMIENTAS MANUALES - CONSORCIO [36.81 h] | 11,949.93 |  |  |  |  |  |  |
| A1-D-01_GEO |  | A1: GEOTEXTIL NO TEJIDO 400 G/M2, INC. COLOCACIÓN | 8d | 2025-08-01 | 2025-08-08 | A1-D-01_EXC FF, A1-D-01_EXUÑ SS | 0d |  | CAPATAZ - CONSORCIO [12.48 h]; OFICIAL - CONSORCIO [124.79 h]; PEON - CONSORCIO [499.15 h]; GEOTEXTIL - CONSORCIO [9865.99]; CAMION GRUA 20 TON - CONSORCIO [18.72 h]; MATERIALES (VARIOS) - CONSORCIO [428.96]; HERRAMIENTAS MANUALES - CONSORCIO [257.37 h] | 120,172.25 |  |  |  |  |  |  |
| A1-D-01_PEDR60 |  | A1: Pedraplén e=60 cm | 3d | 2025-08-01 | 2025-08-03 | A1-D-01_GEO SS | 0d |  | CAPATAZ - CONSORCIO [4.86 h]; OFICIAL - CONSORCIO [24.28 h]; PEON - CONSORCIO [24.28 h]; EXCAVADORA CAT 336 - CONSORCIO [2.43 h]; TRACTOR DE ORUGAS CAT D6D - CONSORCIO [24.28 h]; HERRAMIENTAS MANUALES - CONSORCIO [45.53 h] | 14,003.24 | A2-I-02 07+562@07+666 | 4 | 2 | A2-T1-10 | A2-I-02 | M3 |
| A1-D-01_PEDR30 |  | A1: Pedraplén e=30 cm | 2d | 2025-08-04 | 2025-08-05 | A1-D-01_PEDR60 | 0d |  | CAPATAZ - CONSORCIO [2.97 h]; OFICIAL - CONSORCIO [14.84 h]; PEON - CONSORCIO [14.84 h]; EXCAVADORA CAT 336 - CONSORCIO [1.48 h]; TRACTOR DE ORUGAS CAT D6D - CONSORCIO [14.84 h]; HERRAMIENTAS MANUALES - CONSORCIO [23.37 h] | 8,557.15 | A2-I-02 07+562@07+666 | 5 | 1 | A2-T1-10 | A2-I-02 | M3 |
| A1-D-01_PERF |  | A1: PERFILADO Y COMPACTACIÓN EN ZONA DE CORTE | 11d | 2025-08-04 | 2025-08-14 | A1-D-01_EXC | 3d |  | CAPATAZ - CONSORCIO [8.53 h]; PEON - CONSORCIO [85.3 h]; EXCAVADORA CAT 336 - CONSORCIO [42.65 h]; HERRAMIENTAS MANUALES - CONSORCIO [175.92 h] | 21,311.06 |  |  |  |  |  |  |
| A1-D-01_ROCKU |  | A1: COLOCACION Y ACOMODO DE ROCA EN UÑA DE DIQUE | 5d | 2025-08-04 | 2025-08-08 | A1-D-01_EXUÑ, A1-D-01_GEO SS | 9d |  | CAPATAZ - CONSORCIO [16.37 h]; OFICIAL - CONSORCIO [32.74 h]; PEON - CONSORCIO [163.68 h]; EXCAVADORA CAT 336 - CONSORCIO [32.74 h]; TRACTOR DE ORUGAS CAT D6D - CONSORCIO [8.18 h]; HERRAMIENTAS MANUALES - CONSORCIO [36.83 h] | 23,457.52 |  |  |  |  |  |  |
| A1-D-01_CONFD |  | A1: CONFORMACIÓN DE CUERPO DE DIQUE CON MATERIAL DE PRÉSTAMO | 7d | 2025-08-06 | 2025-08-12 | A1-D-01_PEDR30, A1-D-01_GEO FF | 0d |  | CAPATAZ - CONSORCIO [11.91 h]; OFICIAL - CONSORCIO [59.56 h]; PEON - CONSORCIO [59.56 h]; TRACTOR DE ORUGAS CAT D6D - CONSORCIO [59.56 h]; MOTONIVELADORA 185HP - CONSORCIO [29.78 h]; CAMION CISTERNA (5,000 GLNS.) - CONSORCIO [29.78 h]; HERRAMIENTAS MANUALES - CONSORCIO [93.8 h]; RODILLO LISO VIBRATORIO AUTOPROPULSADO 135HP - CONSORCIO [59.56 h] | 64,367.18 |  |  |  |  |  |  |
| A1-D-01_ROCKT |  | A1: COLOCACION Y ACOMODO DE ROCA EN TALUD DE DIQUE | 5d | 2025-08-13 | 2025-08-17 | A1-D-01_PERF SS, A1-D-01_CONFD, A1-D-01_ROCKU FF, A1-D-01_PERF FF | 0d |  | CAPATAZ - CONSORCIO [16.12 h]; OFICIAL - CONSORCIO [32.23 h]; PEON - CONSORCIO [193.39 h]; EXCAVADORA CAT 336 - CONSORCIO [64.46 h]; TRACTOR DE ORUGAS CAT D6D - CONSORCIO [8.06 h]; HERRAMIENTAS MANUALES - CONSORCIO [24.17 h] | 38,285.7 |  |  |  |  |  |  |
| A1-D-01_CONFCD |  | A1: CONFORMACIÓN DE MATERIAL GRANULAR EN CORONA DE DIQUE | 2d | 2025-08-18 | 2025-08-19 | A1-D-01_CONFD, A1-D-01_ROCKT | 0d |  | CAPATAZ - CONSORCIO [2.34 h]; OFICIAL - CONSORCIO [11.71 h]; PEON - CONSORCIO [11.71 h]; MOTONIVELADORA 185HP - CONSORCIO [11.71 h]; CAMION CISTERNA (5,000 GLNS.) - CONSORCIO [11.71 h]; HERRAMIENTAS MANUALES - CONSORCIO [10.97 h]; RODILLO LISO VIBRATORIO AUTOPROPULSADO 135HP - CONSORCIO [11.71 h] | 11,006.14 |  |  |  |  |  |  |
| A1-D-01_CONFNE |  | A1: CONFORMACIÓN DE RELLENO NO ESTRUCTURAL CON MATERIAL PROPIO | 2d | 2025-08-18 | 2025-08-19 | A1-D-01_CONFCD SS | 0d |  | CAPATAZ - CONSORCIO [4.74 h]; OFICIAL - CONSORCIO [9.48 h]; PEON - CONSORCIO [9.48 h]; TRACTOR DE ORUGAS CAT D6D - CONSORCIO [9.48 h]; HERRAMIENTAS MANUALES - CONSORCIO [21.32 h] | 5,144.33 | A2-I-02 07+562@07+666 | 7 | 1 | A2-T1-15 | A2-I-02 | M3 |
|  | 3 | **A1: DIQUE DE TIERRA COMPACTADA A1-I-01** |  | 2025-08-20 | 2025-09-01 |  |  |  |  |  |  |  |  |  |  |  |
| A1-I-01_EXC |  | A1: EXCAVACIÓN EN TERRENO NATURAL CON EQUIPO | 4d | 2025-08-20 | 2025-08-23 | A1-D-01_ROCKT, A1-D-01_CONFNE | 0d |  | CAPATAZ - CONSORCIO [17.05 h]; PEON - CONSORCIO [34.09 h]; EXCAVADORA CAT 336 - CONSORCIO [34.09 h]; TRACTOR DE ORUGAS CAT D6D - CONSORCIO [17.05 h]; HERRAMIENTAS MANUALES - CONSORCIO [89.49 h] | 24,895.37 |  |  |  |  |  |  |
| A1-I-01_EXUÑ |  | A1: EXCAVACIÓN DE UÑA CON EQUIPO | 3d | 2025-08-21 | 2025-08-23 | A1-I-01_EXC FF, A1-I-01_EXC SS+1d | 0d |  | CAPATAZ - CONSORCIO [0.76 h]; PEON - CONSORCIO [3.8 h]; MOTOBOMBA DE 8" (34HP) - CONSORCIO [3.8 h]; EXCAVADORA CAT 336 - CONSORCIO [3.8 h]; HERRAMIENTAS MANUALES - CONSORCIO [7.13 h] | 2,314.21 |  |  |  |  |  |  |
| A1-I-01_GEO |  | A1: GEOTEXTIL NO TEJIDO 400 G/M2, INC. COLOCACIÓN | 2d | 2025-08-22 | 2025-08-23 | A1-I-01_EXC FF, A1-I-01_EXUÑ FF, A1-I-01_EXUÑ SS | 0d |  | CAPATAZ - CONSORCIO [2.47 h]; OFICIAL - CONSORCIO [24.65 h]; PEON - CONSORCIO [98.61 h]; GEOTEXTIL - CONSORCIO [1949.11]; CAMION GRUA 20 TON - CONSORCIO [3.7 h]; MATERIALES (VARIOS) - CONSORCIO [84.74]; HERRAMIENTAS MANUALES - CONSORCIO [50.85 h] | 23,741.08 |  |  |  |  |  |  |
| A1-I-01_PEDR60 |  | A1: Pedraplén e=60 cm | 2d | 2025-08-22 | 2025-08-23 | A1-I-01_GEO SS | 0d |  | CAPATAZ - CONSORCIO [0.96 h]; OFICIAL - CONSORCIO [4.78 h]; PEON - CONSORCIO [4.78 h]; EXCAVADORA CAT 336 - CONSORCIO [0.48 h]; TRACTOR DE ORUGAS CAT D6D - CONSORCIO [4.78 h]; HERRAMIENTAS MANUALES - CONSORCIO [8.96 h] | 2,756.72 | A2-I-02 07+562@07+666 | 4 | 2 | A2-T1-10 | A2-I-02 | M3 |
| A1-I-01_PEDR30 |  | A1: Pedraplén e=30 cm | 2d | 2025-08-24 | 2025-08-25 | A1-I-01_PEDR60 | 0d |  | CAPATAZ - CONSORCIO [0.59 h]; OFICIAL - CONSORCIO [2.93 h]; PEON - CONSORCIO [2.93 h]; EXCAVADORA CAT 336 - CONSORCIO [0.29 h]; TRACTOR DE ORUGAS CAT D6D - CONSORCIO [2.93 h]; HERRAMIENTAS MANUALES - CONSORCIO [4.61 h] | 1,686.21 | A2-I-02 07+562@07+666 | 5 | 1 | A2-T1-10 | A2-I-02 | M3 |
| A1-I-01_PERF |  | A1: PERFILADO Y COMPACTACIÓN EN ZONA DE CORTE | 2d | 2025-08-24 | 2025-08-25 | A1-I-01_EXC | 4d |  | CAPATAZ - CONSORCIO [1.68 h]; PEON - CONSORCIO [16.84 h]; EXCAVADORA CAT 336 - CONSORCIO [8.42 h]; HERRAMIENTAS MANUALES - CONSORCIO [34.73 h] | 4,207.26 |  |  |  |  |  |  |
| A1-I-01_ROCKU |  | A1: COLOCACION Y ACOMODO DE ROCA EN UÑA DE DIQUE | 2d | 2025-08-24 | 2025-08-25 | A1-I-01_EXUÑ, A1-I-01_GEO SS | 4d |  | CAPATAZ - CONSORCIO [3.17 h]; OFICIAL - CONSORCIO [6.34 h]; PEON - CONSORCIO [31.68 h]; EXCAVADORA CAT 336 - CONSORCIO [6.44 h]; TRACTOR DE ORUGAS CAT D6D - CONSORCIO [1.58 h]; HERRAMIENTAS MANUALES - CONSORCIO [7.13 h] | 4,540.16 |  |  |  |  |  |  |
| A1-I-01_CONFD |  | A1: CONFORMACIÓN DE CUERPO DE DIQUE CON MATERIAL DE PRÉSTAMO | 2d | 2025-08-26 | 2025-08-27 | A1-I-01_PEDR30, A1-I-01_GEO FF | 0d |  | CAPATAZ - CONSORCIO [2.48 h]; OFICIAL - CONSORCIO [12.39 h]; PEON - CONSORCIO [12.39 h]; TRACTOR DE ORUGAS CAT D6D - CONSORCIO [12.39 h]; MOTONIVELADORA 185HP - CONSORCIO [6.19 h]; CAMION CISTERNA (5,000 GLNS.) - CONSORCIO [6.19 h]; HERRAMIENTAS MANUALES - CONSORCIO [19.51 h]; RODILLO LISO VIBRATORIO AUTOPROPULSADO 135HP - CONSORCIO [12.39 h] | 13,388.89 |  |  |  |  |  |  |
| A1-I-01_ROCKT |  | A1: COLOCACION Y ACOMODO DE ROCA EN TALUD DE DIQUE | 2d | 2025-08-28 | 2025-08-29 | A1-I-01_PERF SS, A1-I-01_CONFD, A1-I-01_ROCKU FF, A1-I-01_PERF FF | 0d |  | CAPATAZ - CONSORCIO [3.24 h]; OFICIAL - CONSORCIO [6.48 h]; PEON - CONSORCIO [38.88 h]; EXCAVADORA CAT 336 - CONSORCIO [12.96 h]; TRACTOR DE ORUGAS CAT D6D - CONSORCIO [1.62 h]; HERRAMIENTAS MANUALES - CONSORCIO [4.86 h] | 7,697.06 |  |  |  |  |  |  |
| A1-I-01_CONFCD |  | A1: CONFORMACIÓN DE MATERIAL GRANULAR EN CORONA DE DIQUE | 2d | 2025-08-30 | 2025-08-31 | A1-I-01_CONFD, A1-I-01_ROCKT | 0d |  | CAPATAZ - CONSORCIO [0.45 h]; OFICIAL - CONSORCIO [2.27 h]; PEON - CONSORCIO [2.27 h]; MOTONIVELADORA 185HP - CONSORCIO [2.27 h]; CAMION CISTERNA (5,000 GLNS.) - CONSORCIO [2.27 h]; HERRAMIENTAS MANUALES - CONSORCIO [5.13 h]; RODILLO LISO VIBRATORIO AUTOPROPULSADO 135HP - CONSORCIO [2.27 h] | 2,130.21 |  |  |  |  |  |  |
| A1-I-01_CONFNE |  | A1: CONFORMACIÓN DE RELLENO NO ESTRUCTURAL CON MATERIAL PROPIO | 1d | 2025-09-01 | 2025-09-01 | A1-I-01_CONFCD | 0d |  | CAPATAZ - CONSORCIO [1.14 h]; OFICIAL - CONSORCIO [2.28 h]; PEON - CONSORCIO [2.28 h]; TRACTOR DE ORUGAS CAT D6D - CONSORCIO [2.28 h]; HERRAMIENTAS MANUALES - CONSORCIO [5.13 h] | 1,238.76 | A2-I-02 07+562@07+666 | 7 | 1 | A2-T1-15 | A2-I-02 | M3 |

Notes:
- OA-HDP-A1: Expenses: HERRAMIENTAS MANUALES 6.06

| ID | WBS | Activity | Duration | Start | Finish | Predecessors | Total float | Free float | Resources | Cost | OHLA-DAT | OHLA-REND | OHLA-DUR | OHLA_ESTRUCTURA OFERTA_A2-T1 | OHLA Diques | Unidad |
| --- | --- | --- | --- | --- | --- | --- | --- | --- | --- | --- | --- | --- | --- | --- | --- | --- |
|  | 4 | **A1: DIQUE DE TIERRA COMPACTADA A1-D-02** |  | 2025-09-07 | 2025-09-20 |  |  |  |  |  |  |  |  |  |  |  |
| A1-D-02_EXC |  | A1: EXCAVACIÓN EN TERRENO NATURAL CON EQUIPO | 4d | 2025-09-07 | 2025-09-10 | A1-I-02_ROCKT | 0d |  | CAPATAZ - CONSORCIO [17.78 h]; PEON - CONSORCIO [35.56 h]; EXCAVADORA CAT 336 - CONSORCIO [35.56 h]; TRACTOR DE ORUGAS CAT D6D - CONSORCIO [17.78 h]; HERRAMIENTAS MANUALES - CONSORCIO [93.34 h] | 25,966.62 |  |  |  |  |  |  |
| A1-D-02_EXUÑ |  | A1: EXCAVACIÓN DE UÑA CON EQUIPO | 1d | 2025-09-10 | 2025-09-10 | A1-D-02_EXC FF, A1-D-02_EXC SS | 0d |  | CAPATAZ - CONSORCIO [0.76 h]; PEON - CONSORCIO [3.78 h]; MOTOBOMBA DE 8" (34HP) - CONSORCIO [3.78 h]; EXCAVADORA CAT 336 - CONSORCIO [3.78 h]; HERRAMIENTAS MANUALES - CONSORCIO [7.08 h] | 2,299.32 |  |  |  |  |  |  |
| A1-D-02_GEO |  | A1: GEOTEXTIL NO TEJIDO 400 G/M2, INC. COLOCACIÓN | 2d | 2025-09-10 | 2025-09-11 | A1-D-02_EXC FF, A1-D-02_EXUÑ SS | 0d |  | CAPATAZ - CONSORCIO [2.83 h]; OFICIAL - CONSORCIO [28.3 h]; PEON - CONSORCIO [113.2 h]; GEOTEXTIL - CONSORCIO [2237.45]; CAMION GRUA 20 TON - CONSORCIO [4.24 h]; MATERIALES (VARIOS) - CONSORCIO [97.28]; HERRAMIENTAS MANUALES - CONSORCIO [58.37 h] | 27,253.18 |  |  |  |  |  |  |
| A1-D-02_PEDR60 |  | A1: Pedraplén e=60 cm | 2d | 2025-09-10 | 2025-09-11 | A1-D-02_GEO SS | 0d |  | CAPATAZ - CONSORCIO [1.09 h]; OFICIAL - CONSORCIO [5.44 h]; PEON - CONSORCIO [5.44 h]; EXCAVADORA CAT 336 - CONSORCIO [0.54 h]; TRACTOR DE ORUGAS CAT D6D - CONSORCIO [5.44 h]; HERRAMIENTAS MANUALES - CONSORCIO [10.19 h] | 3,135.27 | A2-I-02 07+562@07+666 | 4 | 2 | A2-T1-10 | A2-I-02 | M3 |
| A1-D-02_PERF |  | A1: PERFILADO Y COMPACTACIÓN EN ZONA DE CORTE | 2d | 2025-09-10 | 2025-09-11 | A1-D-02_EXC SS+3d | 5d |  | CAPATAZ - CONSORCIO [2.13 h]; PEON - CONSORCIO [21.34 h]; EXCAVADORA CAT 336 - CONSORCIO [10.67 h]; HERRAMIENTAS MANUALES - CONSORCIO [44.02 h] | 5,332.58 |  |  |  |  |  |  |
| A1-D-02_ROCKU |  | A1: COLOCACION Y ACOMODO DE ROCA EN UÑA DE DIQUE | 2d | 2025-09-11 | 2025-09-12 | A1-D-02_EXUÑ, A1-D-02_GEO SS | 4d |  | CAPATAZ - CONSORCIO [3.22 h]; OFICIAL - CONSORCIO [6.44 h]; PEON - CONSORCIO [32.22 h]; EXCAVADORA CAT 336 - CONSORCIO [6.44 h]; TRACTOR DE ORUGAS CAT D6D - CONSORCIO [1.61 h]; HERRAMIENTAS MANUALES - CONSORCIO [7.25 h] | 4,616.98 |  |  |  |  |  |  |
| A1-D-02_PEDR30 |  | A1: Pedraplén e=30 cm | 2d | 2025-09-12 | 2025-09-13 | A1-D-02_PEDR60 | 0d |  | CAPATAZ - CONSORCIO [0.66 h]; OFICIAL - CONSORCIO [3.31 h]; PEON - CONSORCIO [3.31 h]; EXCAVADORA CAT 336 - CONSORCIO [0.33 h]; TRACTOR DE ORUGAS CAT D6D - CONSORCIO [3.31 h]; HERRAMIENTAS MANUALES - CONSORCIO [5.21 h] | 1,907.7 | A2-I-02 07+562@07+666 | 5 | 1 | A2-T1-10 | A2-I-02 | M3 |
| A1-D-02_CONFD |  | A1: CONFORMACIÓN DE CUERPO DE DIQUE CON MATERIAL DE PRÉSTAMO | 3d | 2025-09-14 | 2025-09-16 | A1-D-02_PEDR30, A1-D-02_GEO FF | 0d |  | CAPATAZ - CONSORCIO [4.71 h]; OFICIAL - CONSORCIO [23.54 h]; PEON - CONSORCIO [23.54 h]; TRACTOR DE ORUGAS CAT D6D - CONSORCIO [23.54 h]; MOTONIVELADORA 185HP - CONSORCIO [11.77 h]; CAMION CISTERNA (5,000 GLNS.) - CONSORCIO [11.77 h]; HERRAMIENTAS MANUALES - CONSORCIO [37.07 h]; RODILLO LISO VIBRATORIO AUTOPROPULSADO 135HP - CONSORCIO [23.54 h] | 25,438.7 |  |  |  |  |  |  |
| A1-D-02_ROCKT |  | A1: COLOCACION Y ACOMODO DE ROCA EN TALUD DE DIQUE | 2d | 2025-09-15 | 2025-09-16 | A1-D-02_PERF SS, A1-D-02_CONFD FF, A1-D-02_ROCKU FF, A1-D-02_PERF FF, OA-TMR-03-A1 FF, OA-TMR-04-A1 FF | 0d |  | CAPATAZ - CONSORCIO [4.47 h]; OFICIAL - CONSORCIO [8.95 h]; PEON - CONSORCIO [53.69 h]; EXCAVADORA CAT 336 - CONSORCIO [17.9 h]; TRACTOR DE ORUGAS CAT D6D - CONSORCIO [2.24 h]; HERRAMIENTAS MANUALES - CONSORCIO [6.71 h] | 10,629.07 |  |  |  |  |  |  |
| A1-D-02_CONFCD |  | A1: CONFORMACIÓN DE MATERIAL GRANULAR EN CORONA DE DIQUE | 2d | 2025-09-17 | 2025-09-18 | A1-D-02_CONFD, A1-D-02_ROCKT | 0d |  | CAPATAZ - CONSORCIO [0.36 h]; OFICIAL - CONSORCIO [1.82 h]; PEON - CONSORCIO [1.82 h]; MOTONIVELADORA 185HP - CONSORCIO [1.82 h]; CAMION CISTERNA (5,000 GLNS.) - CONSORCIO [1.82 h]; HERRAMIENTAS MANUALES - CONSORCIO [1.7 h]; RODILLO LISO VIBRATORIO AUTOPROPULSADO 135HP - CONSORCIO [1.82 h] | 1,707.78 |  |  |  |  |  |  |
| A1-D-02_CONFNE |  | A1: CONFORMACIÓN DE RELLENO NO ESTRUCTURAL CON MATERIAL PROPIO | 2d | 2025-09-19 | 2025-09-20 | A1-D-02_CONFCD | 0d |  | CAPATAZ - CONSORCIO [2.76 h]; OFICIAL - CONSORCIO [5.51 h]; PEON - CONSORCIO [5.51 h]; TRACTOR DE ORUGAS CAT D6D - CONSORCIO [5.51 h]; HERRAMIENTAS MANUALES - CONSORCIO [12.41 h] | 2,993.72 | A2-I-02 07+562@07+666 | 7 | 1 | A2-T1-15 | A2-I-02 | M3 |
|  | 5 | **A1: DIQUE DE TIERRA COMPACTADA A1-I-02** |  | 2025-08-30 | 2025-09-10 |  |  |  |  |  |  |  |  |  |  |  |
| A1-I-02_EXC |  | A1: EXCAVACIÓN EN TERRENO NATURAL CON EQUIPO | 3d | 2025-08-30 | 2025-09-01 | A1-I-01_ROCKT, A1-I-01_CONFNE FF | 0d |  | CAPATAZ - CONSORCIO [25.3 h]; PEON - CONSORCIO [50.59 h]; EXCAVADORA CAT 336 - CONSORCIO [50.59 h]; TRACTOR DE ORUGAS CAT D6D - CONSORCIO [25.3 h]; HERRAMIENTAS MANUALES - CONSORCIO [132.8 h] | 36,943.52 |  |  |  |  |  |  |
| A1-I-02_EXUÑ |  | A1: EXCAVACIÓN DE UÑA CON EQUIPO | 2d | 2025-08-31 | 2025-09-01 | A1-I-02_EXC FF, A1-I-02_EXC SS | 0d |  | CAPATAZ - CONSORCIO [0.83 h]; PEON - CONSORCIO [4.14 h]; MOTOBOMBA DE 8" (34HP) - CONSORCIO [4.14 h]; EXCAVADORA CAT 336 - CONSORCIO [4.14 h]; HERRAMIENTAS MANUALES - CONSORCIO [7.77 h] | 2,522.45 |  |  |  |  |  |  |
| A1-I-02_GEO |  | A1: GEOTEXTIL NO TEJIDO 400 G/M2, INC. COLOCACIÓN | 2d | 2025-08-31 | 2025-09-01 | A1-I-02_EXC FF, A1-I-02_EXUÑ SS | 0d |  | CAPATAZ - CONSORCIO [3.12 h]; OFICIAL - CONSORCIO [31.16 h]; PEON - CONSORCIO [124.63 h]; GEOTEXTIL - CONSORCIO [2463.48]; CAMION GRUA 20 TON - CONSORCIO [4.67 h]; MATERIALES (VARIOS) - CONSORCIO [107.11]; HERRAMIENTAS MANUALES - CONSORCIO [64.26 h] | 30,006.36 |  |  |  |  |  |  |
| A1-I-02_PEDR60 |  | A1: Pedraplén e=60 cm | 2d | 2025-08-31 | 2025-09-01 | A1-I-02_GEO SS | 0d |  | CAPATAZ - CONSORCIO [1.91 h]; OFICIAL - CONSORCIO [9.56 h]; PEON - CONSORCIO [9.56 h]; EXCAVADORA CAT 336 - CONSORCIO [0.96 h]; TRACTOR DE ORUGAS CAT D6D - CONSORCIO [9.56 h]; HERRAMIENTAS MANUALES - CONSORCIO [17.93 h] | 5,512.94 | A2-I-02 07+562@07+666 | 4 | 2 | A2-T1-10 | A2-I-02 | M3 |
| A1-I-02_PEDR30 |  | A1: Pedraplén e=30 cm | 2d | 2025-09-02 | 2025-09-03 | A1-I-02_PEDR60 | 0d |  | CAPATAZ - CONSORCIO [0.72 h]; OFICIAL - CONSORCIO [3.61 h]; PEON - CONSORCIO [3.61 h]; EXCAVADORA CAT 336 - CONSORCIO [0.36 h]; TRACTOR DE ORUGAS CAT D6D - CONSORCIO [3.61 h]; HERRAMIENTAS MANUALES - CONSORCIO [5.69 h] | 2,082.44 | A2-I-02 07+562@07+666 | 5 | 1 | A2-T1-10 | A2-I-02 | M3 |
| A1-I-02_PERF |  | A1: PERFILADO Y COMPACTACIÓN EN ZONA DE CORTE | 3d | 2025-09-02 | 2025-09-04 | A1-I-02_EXC SS+3d | 2d |  | CAPATAZ - CONSORCIO [2.17 h]; PEON - CONSORCIO [21.75 h]; EXCAVADORA CAT 336 - CONSORCIO [10.87 h]; HERRAMIENTAS MANUALES - CONSORCIO [44.86 h] | 5,433.68 |  |  |  |  |  |  |
| A1-I-02_ROCKU |  | A1: COLOCACION Y ACOMODO DE ROCA EN UÑA DE DIQUE | 2d | 2025-09-02 | 2025-09-03 | A1-I-02_EXUÑ, A1-I-02_GEO SS | 3d |  | CAPATAZ - CONSORCIO [3.45 h]; OFICIAL - CONSORCIO [6.91 h]; PEON - CONSORCIO [34.53 h]; EXCAVADORA CAT 336 - CONSORCIO [6.91 h]; TRACTOR DE ORUGAS CAT D6D - CONSORCIO [1.73 h]; HERRAMIENTAS MANUALES - CONSORCIO [7.77 h] | 4,948.71 |  |  |  |  |  |  |
| A1-I-02_CONFD |  | A1: CONFORMACIÓN DE CUERPO DE DIQUE CON MATERIAL DE PRÉSTAMO | 3d | 2025-09-04 | 2025-09-06 | A1-I-02_PEDR30, A1-I-02_GEO FF | 0d |  | CAPATAZ - CONSORCIO [4.92 h]; OFICIAL - CONSORCIO [24.6 h]; PEON - CONSORCIO [24.6 h]; TRACTOR DE ORUGAS CAT D6D - CONSORCIO [24.6 h]; MOTONIVELADORA 185HP - CONSORCIO [12.3 h]; CAMION CISTERNA (5,000 GLNS.) - CONSORCIO [12.3 h]; HERRAMIENTAS MANUALES - CONSORCIO [38.75 h]; RODILLO LISO VIBRATORIO AUTOPROPULSADO 135HP - CONSORCIO [24.6 h] | 26,588.62 |  |  |  |  |  |  |
| A1-I-02_ROCKT |  | A1: COLOCACION Y ACOMODO DE ROCA EN TALUD DE DIQUE | 2d | 2025-09-05 | 2025-09-06 | A1-I-02_PERF SS, A1-I-02_CONFD FF, A1-I-02_ROCKU FF, A1-I-02_PERF FF | 0d |  | CAPATAZ - CONSORCIO [4.56 h]; OFICIAL - CONSORCIO [9.12 h]; PEON - CONSORCIO [54.73 h]; EXCAVADORA CAT 336 - CONSORCIO [18.24 h]; TRACTOR DE ORUGAS CAT D6D - CONSORCIO [2.28 h]; HERRAMIENTAS MANUALES - CONSORCIO [6.84 h] | 10,835.74 |  |  |  |  |  |  |
| A1-I-02_CONFCD |  | A1: CONFORMACIÓN DE MATERIAL GRANULAR EN CORONA DE DIQUE | 2d | 2025-09-07 | 2025-09-08 | A1-I-02_CONFD, A1-I-02_ROCKT | 7d | 0d | CAPATAZ - CONSORCIO [0.33 h]; OFICIAL - CONSORCIO [1.64 h]; PEON - CONSORCIO [1.64 h]; MOTONIVELADORA 185HP - CONSORCIO [1.64 h]; CAMION CISTERNA (5,000 GLNS.) - CONSORCIO [1.64 h]; HERRAMIENTAS MANUALES - CONSORCIO [1.53 h]; RODILLO LISO VIBRATORIO AUTOPROPULSADO 135HP - CONSORCIO [1.64 h] | 1,538.4 |  |  |  |  |  |  |
| A1-I-02_CONFNE |  | A1: CONFORMACIÓN DE RELLENO NO ESTRUCTURAL CON MATERIAL PROPIO | 2d | 2025-09-09 | 2025-09-10 | A1-I-02_CONFCD | 7d | 0d | CAPATAZ - CONSORCIO [3.35 h]; OFICIAL - CONSORCIO [6.7 h]; PEON - CONSORCIO [6.7 h]; TRACTOR DE ORUGAS CAT D6D - CONSORCIO [6.7 h]; HERRAMIENTAS MANUALES - CONSORCIO [15.08 h] | 3,637.18 | A2-I-02 07+562@07+666 | 7 | 1 | A2-T1-15 | A2-I-02 | M3 |

| ID | WBS | Activity | Duration | Start | Finish | Predecessors | Total float | Free float | Resources | Cost | OHLA-DAT | OHLA-REND | OHLA-DUR | OHLA_ESTRUCTURA OFERTA_A2-T1 | OHLA Diques | Unidad |
| --- | --- | --- | --- | --- | --- | --- | --- | --- | --- | --- | --- | --- | --- | --- | --- | --- |
|  | 02 | **DIQUES DE TIERRA COMPACTADA CON ENROCADO - SUBPROYECTO A2T1** |  | 2025-07-22 | 2025-08-29 |  |  |  |  |  |  |  |  |  |  |  |
|  | 7 | **A2T1: DIQUE DE TIERRA COMPACTADA A2-D-01** |  | 2025-08-09 | 2025-08-29 |  |  |  |  |  |  |  |  |  |  |  |
| A2-D-01_EXC |  | A2T1: EXCAVACIÓN EN TERRENO NATURAL CON EQUIPO | 5d | 2025-08-09 | 2025-08-13 | A2-I-02_ROCKT, A2-I-02_CONFCD | 20d | 0d | CAPATAZ - CONSORCIO [36.84 h]; PEON - CONSORCIO [73.68 h]; EXCAVADORA CAT 336 - CONSORCIO [73.68 h]; TRACTOR DE ORUGAS CAT D6D - CONSORCIO [36.84 h]; HERRAMIENTAS MANUALES - CONSORCIO [193.42 h] | 53,806.66 |  |  |  |  |  |  |
| A2-D-01_GEO |  | A2T1: GEOTEXTIL NO TEJIDO 400 G/M2, INC. COLOCACIÓN | 2d | 2025-08-12 | 2025-08-13 | A2-D-01_PERF SS, A2-D-01_EXC FF | 20d | 0d | CAPATAZ - CONSORCIO [0.83 h]; OFICIAL - CONSORCIO [8.26 h]; PEON - CONSORCIO [33.06 h]; GEOTEXTIL - CONSORCIO [653.37]; CAMION GRUA 20 TON - CONSORCIO [1.24 h]; MATERIALES (VARIOS) - CONSORCIO [28.41]; HERRAMIENTAS MANUALES - CONSORCIO [17.04 h] | 7,958.38 |  |  |  |  |  |  |
| A2-D-01_PERF |  | A2T1: PERFILADO EN ZONA DE CORTE EN FUNDACIÓN Y TALUD | 2d | 2025-08-12 | 2025-08-13 | A2-D-01_EXC FF, A2-D-01_EXC SS | 20d | 0d | CAPATAZ - CONSORCIO [1.52 h]; PEON - CONSORCIO [15.19 h]; EXCAVADORA CAT 336 - CONSORCIO [7.6 h]; HERRAMIENTAS MANUALES - CONSORCIO [31.34 h] | 3,796.41 |  |  |  |  |  |  |
| A2-D-01_PEDR60 |  | A2T1: Pedraplén e=60 cm | 4d | 2025-08-13 | 2025-08-16 | A2-D-01_GEO SS+1d | 20d | 0d | CAPATAZ - CONSORCIO [6.63 h]; OFICIAL - CONSORCIO [33.14 h]; PEON - CONSORCIO [33.14 h]; EXCAVADORA CAT 336 - CONSORCIO [3.31 h]; TRACTOR DE ORUGAS CAT D6D - CONSORCIO [33.14 h]; HERRAMIENTAS MANUALES - CONSORCIO [62.15 h] | 19,112.17 | A2-I-02 07+562@07+666 | 4 | 2 | A2-T1-10 | A2-I-02 | M3 |
| A2-D-01_EXUÑ |  | A2T1: EXCAVACIÓN DE UÑA CON EQUIPO | 2d | 2025-08-14 | 2025-08-15 | A2-D-01_EXC, A2-D-01_EXC SS, OA-TME-01-A2T1 FF, OA-TME-02-A2T1 FF | 25d | 0d | CAPATAZ - CONSORCIO [1.58 h]; PEON - CONSORCIO [7.92 h]; MOTOBOMBA DE 8" (34HP) - CONSORCIO [7.92 h]; EXCAVADORA CAT 336 - CONSORCIO [7.92 h]; HERRAMIENTAS MANUALES - CONSORCIO [14.85 h] | 4,821.27 |  |  |  |  |  |  |
| A2-D-01_ROCKU |  | A2T1: COLOCACION Y ACOMODO DE ROCA EN UÑA DE DIQUE | 3d | 2025-08-14 | 2025-08-16 | A2-D-01_EXUÑ SS, A2-D-01_GEO SS, A2-D-01_GEO FF | 25d | 5d | CAPATAZ - CONSORCIO [6.6 h]; OFICIAL - CONSORCIO [13.21 h]; PEON - CONSORCIO [66.03 h]; EXCAVADORA CAT 336 - CONSORCIO [13.21 h]; TRACTOR DE ORUGAS CAT D6D - CONSORCIO [3.3 h]; HERRAMIENTAS MANUALES - CONSORCIO [14.86 h] | 9,462.5 |  |  |  |  |  |  |
| A2-D-01_PEDR30 |  | A2T1: Pedraplén e=30 cm | 1d | 2025-08-17 | 2025-08-17 | A2-D-01_PEDR60 | 20d | 0d | CAPATAZ - CONSORCIO [1.14 h]; OFICIAL - CONSORCIO [5.7 h]; PEON - CONSORCIO [5.7 h]; EXCAVADORA CAT 336 - CONSORCIO [0.57 h]; TRACTOR DE ORUGAS CAT D6D - CONSORCIO [5.7 h]; HERRAMIENTAS MANUALES - CONSORCIO [8.98 h] | 3,287.31 | A2-I-02 07+562@07+666 | 5 | 1 | A2-T1-10 | A2-I-02 | M3 |
| A2-D-01_CONFD |  | A2T1: CONFORMACIÓN DE CUERPO DE DIQUE CON MATERIAL PROPIO | 4d | 2025-08-18 | 2025-08-21 | A2-D-01_PEDR30 | 20d | 0d | CAPATAZ - CONSORCIO [8.88 h]; OFICIAL - CONSORCIO [44.42 h]; PEON - CONSORCIO [44.42 h]; TRACTOR DE ORUGAS CAT D6D - CONSORCIO [44.42 h]; MOTONIVELADORA 185HP - CONSORCIO [22.21 h]; CAMION CISTERNA (5,000 GLNS.) - CONSORCIO [22.21 h]; HERRAMIENTAS MANUALES - CONSORCIO [49.97 h]; RODILLO LISO VIBRATORIO AUTOPROPULSADO 135HP - CONSORCIO [44.42 h] | 48,005.32 |  |  |  |  |  |  |
| A2-D-01_ROCKT |  | A2T1: COLOCACION Y ACOMODO DE ROCA EN TALUD DE DIQUE | 2d | 2025-08-22 | 2025-08-23 | A2-D-01_PERF SS, A2-D-01_ROCKU, A2-D-01_CONFD, OA-TMR-01-A2T1 FF, OA-TMR-02-A2T1 FF | 20d | 0d | CAPATAZ - CONSORCIO [5.95 h]; OFICIAL - CONSORCIO [13.41 h]; PEON - CONSORCIO [71.38 h]; EXCAVADORA CAT 336 - CONSORCIO [23.79 h]; TRACTOR DE ORUGAS CAT D6D - CONSORCIO [2.97 h]; HERRAMIENTAS MANUALES - CONSORCIO [8.92 h] | 14,130.27 |  |  |  |  |  |  |
| A2-D-01_CONFCD |  | A2T1: CONFORMACIÓN DE MATERIAL GRANULAR EN CORONA DE DIQUE | 2d | 2025-08-24 | 2025-08-25 | A2-D-01_ROCKT, A2-D-01_EXUÑ, A2-D-01_PERF, A2-D-01_CONFD, A2-D-01_ROCKU, OA-TMG-01-A2T1 FF, OA-TMG-02-A2T1 FF | 20d | 0d | CAPATAZ - CONSORCIO [0.61 h]; OFICIAL - CONSORCIO [3.04 h]; PEON - CONSORCIO [3.04 h]; MOTONIVELADORA 185HP - CONSORCIO [3.04 h]; CAMION CISTERNA (5,000 GLNS.) - CONSORCIO [3.04 h]; HERRAMIENTAS MANUALES - CONSORCIO [2.85 h]; RODILLO LISO VIBRATORIO AUTOPROPULSADO 135HP - CONSORCIO [3.04 h] | 2,862.87 |  |  |  |  |  |  |
| A2-D-01_CONFNE |  | A2T1: CONFORMACIÓN DE RELLENO NO ESTRUCTURAL CON MATERIAL PROPIO | 4d | 2025-08-26 | 2025-08-29 | A2-D-01_CONFCD, TP-TOPO-A2T1, SSO-A2T1 | 20d |  | CAPATAZ - CONSORCIO [6.93 h]; OFICIAL - CONSORCIO [13.85 h]; PEON - CONSORCIO [13.85 h]; TRACTOR DE ORUGAS CAT D6D - CONSORCIO [13.85 h]; HERRAMIENTAS MANUALES - CONSORCIO [31.17 h] | 7,519.08 | A2-I-02 07+562@07+666 | 7 | 1 | A2-T1-15 | A2-I-02 | M3 |
|  | 12 | **A2T1: DIQUE DE TIERRA COMPACTADA A2-I-02** |  | 2025-07-22 | 2025-08-13 |  |  |  |  |  |  |  |  |  |  |  |
| A2-I-02_EXC |  | A2T1: EXCAVACIÓN EN TERRENO NATURAL CON EQUIPO | 8d | 2025-07-22 | 2025-07-29 | DESV-RIO-A2T1 SS, MOV-01-A2T1, DEBROC-A2T1 FF | 20d | 0d | CAPATAZ - CONSORCIO [31.26 h]; PEON - CONSORCIO [62.53 h]; EXCAVADORA CAT 336 - CONSORCIO [62.53 h]; TRACTOR DE ORUGAS CAT D6D - CONSORCIO [31.26 h]; HERRAMIENTAS MANUALES - CONSORCIO [164.13 h] | 45,659.16 |  |  |  |  |  |  |
| A2-I-02_PERF |  | A2T1: PERFILADO EN ZONA DE CORTE EN FUNDACIÓN Y TALUD | 3d | 2025-07-27 | 2025-07-29 | A2-I-02_EXC FF, A2-I-02_EXC SS | 21d | 1d | CAPATAZ - CONSORCIO [2.03 h]; PEON - CONSORCIO [20.29 h]; EXCAVADORA CAT 336 - CONSORCIO [10.15 h]; HERRAMIENTAS MANUALES - CONSORCIO [41.85 h] | 5,069.65 |  |  |  |  |  |  |
| A2-I-02_EXUÑ |  | A2T1: EXCAVACIÓN DE UÑA CON EQUIPO | 2d | 2025-07-28 | 2025-07-29 | A2-I-02_EXC FF, A2-I-02_EXC SS | 26d | 0d | CAPATAZ - CONSORCIO [1.76 h]; PEON - CONSORCIO [8.8 h]; MOTOBOMBA DE 8" (34HP) - CONSORCIO [8.8 h]; EXCAVADORA CAT 336 - CONSORCIO [8.8 h]; HERRAMIENTAS MANUALES - CONSORCIO [16.49 h] | 5,353.04 |  |  |  |  |  |  |
| A2-I-02_GEO |  | A2T1: GEOTEXTIL NO TEJIDO 400 G/M2, INC. COLOCACIÓN | 2d | 2025-07-28 | 2025-07-29 | A2-I-02_PERF SS, A2-I-02_EXC FF | 20d | 0d | CAPATAZ - CONSORCIO [0.95 h]; OFICIAL - CONSORCIO [9.47 h]; PEON - CONSORCIO [37.89 h]; GEOTEXTIL - CONSORCIO [748.88]; CAMION GRUA 20 TON - CONSORCIO [1.42 h]; MATERIALES (VARIOS) - CONSORCIO [32.56]; HERRAMIENTAS MANUALES - CONSORCIO [19.54 h] | 9,121.7 |  |  |  |  |  |  |
| A2-I-02_ROCKU |  | A2T1: COLOCACION Y ACOMODO DE ROCA EN UÑA DE DIQUE | 3d | 2025-07-28 | 2025-07-30 | A2-I-02_EXUÑ SS, A2-I-02_GEO SS, A2-I-02_GEO FF | 26d | 6d | CAPATAZ - CONSORCIO [7.33 h]; OFICIAL - CONSORCIO [14.66 h]; PEON - CONSORCIO [73.29 h]; EXCAVADORA CAT 336 - CONSORCIO [14.66 h]; TRACTOR DE ORUGAS CAT D6D - CONSORCIO [3.66 h]; HERRAMIENTAS MANUALES - CONSORCIO [16.49 h] | 10,503.91 |  |  |  |  |  |  |
| A2-I-02_PEDR60 |  | A2T1: Pedraplén e=60 cm | 3d | 2025-07-29 | 2025-07-31 | A2-I-02_GEO SS+1d | 20d | 0d | CAPATAZ - CONSORCIO [6.88 h]; OFICIAL - CONSORCIO [34.38 h]; PEON - CONSORCIO [34.38 h]; EXCAVADORA CAT 336 - CONSORCIO [3.44 h]; TRACTOR DE ORUGAS CAT D6D - CONSORCIO [34.38 h]; HERRAMIENTAS MANUALES - CONSORCIO [64.46 h] | 19,822.66 | A2-I-02 07+562@07+666 | 4 | 2 | A2-T1-10 | A2-I-02 | M3 |
| A2-I-02_PEDR30 |  | A2T1: Pedraplén e=30 cm | 1d | 2025-08-01 | 2025-08-01 | A2-I-02_PEDR60 | 20d | 0d | CAPATAZ - CONSORCIO [1.19 h]; OFICIAL - CONSORCIO [5.95 h]; PEON - CONSORCIO [5.95 h]; EXCAVADORA CAT 336 - CONSORCIO [0.6 h]; TRACTOR DE ORUGAS CAT D6D - CONSORCIO [5.95 h]; HERRAMIENTAS MANUALES - CONSORCIO [9.38 h] | 3,432.85 | A2-I-02 07+562@07+666 | 5 | 1 | A2-T1-10 | A2-I-02 | M3 |
| A2-I-02_CONFD |  | A2T1: CONFORMACIÓN DE CUERPO DE DIQUE CON MATERIAL PROPIO | 4d | 2025-08-02 | 2025-08-05 | A2-I-02_PEDR30 | 20d | 0d | CAPATAZ - CONSORCIO [8.93 h]; OFICIAL - CONSORCIO [44.65 h]; PEON - CONSORCIO [44.65 h]; TRACTOR DE ORUGAS CAT D6D - CONSORCIO [44.65 h]; MOTONIVELADORA 185HP - CONSORCIO [22.32 h]; CAMION CISTERNA (5,000 GLNS.) - CONSORCIO [22.32 h]; HERRAMIENTAS MANUALES - CONSORCIO [50.23 h]; RODILLO LISO VIBRATORIO AUTOPROPULSADO 135HP - CONSORCIO [44.65 h] | 48,253.16 |  |  |  |  |  |  |
| A2-I-02_ROCKT |  | A2T1: COLOCACION Y ACOMODO DE ROCA EN TALUD DE DIQUE | 2d | 2025-08-06 | 2025-08-07 | A2-I-02_PERF SS, A2-I-02_ROCKU, A2-I-02_CONFD | 20d | 0d | CAPATAZ - CONSORCIO [6.7 h]; OFICIAL - CONSORCIO [13.4 h]; PEON - CONSORCIO [80.39 h]; EXCAVADORA CAT 336 - CONSORCIO [26.8 h]; TRACTOR DE ORUGAS CAT D6D - CONSORCIO [3.35 h]; HERRAMIENTAS MANUALES - CONSORCIO [10.05 h] | 15,914.37 |  |  |  |  |  |  |
| A2-I-02_CONFCD |  | A2T1: CONFORMACIÓN DE MATERIAL GRANULAR EN CORONA DE DIQUE | 1d | 2025-08-08 | 2025-08-08 | A2-I-02_ROCKT, A2-I-02_EXUÑ, A2-I-02_PERF, A2-I-02_CONFD, A2-I-02_ROCKU | 20d | 0d | CAPATAZ - CONSORCIO [0.94 h]; OFICIAL - CONSORCIO [4.68 h]; PEON - CONSORCIO [4.68 h]; MOTONIVELADORA 185HP - CONSORCIO [4.68 h]; CAMION CISTERNA (5,000 GLNS.) - CONSORCIO [4.68 h]; HERRAMIENTAS MANUALES - CONSORCIO [4.39 h]; RODILLO LISO VIBRATORIO AUTOPROPULSADO 135HP - CONSORCIO [4.68 h] | 4,401.56 |  |  |  |  |  |  |
| A2-I-02_CONFNE |  | A2T1: CONFORMACIÓN DE RELLENO NO ESTRUCTURAL CON MATERIAL PROPIO | 5d | 2025-08-09 | 2025-08-13 | A2-I-02_CONFCD | 36d |  | CAPATAZ - CONSORCIO [8.34 h]; OFICIAL - CONSORCIO [16.68 h]; PEON - CONSORCIO [16.68 h]; TRACTOR DE ORUGAS CAT D6D - CONSORCIO [16.68 h]; HERRAMIENTAS MANUALES - CONSORCIO [37.54 h] | 9,056.03 | A2-I-02 07+562@07+666 | 7 | 1 | A2-T1-15 | A2-I-02 | M3 |

| ID | WBS | Activity | Type | Duration | Start | Finish | Predecessors | Total float | Free float | Resources | Cost |
| --- | --- | --- | --- | --- | --- | --- | --- | --- | --- | --- | --- |
|  | 03 | **RAMPAS (Subproyecto A-1)** |  |  | 2025-09-01 | 2025-09-23 |  |  |  |  |  |
|  | 1 | **RAMPA - (A1-RA-I-PP)** |  |  | 2025-09-11 | 2025-09-13 |  |  |  |  |  |
| A1-RA-I-PP-EXCTN |  | A1: EXCAVACIÓN EN TERRENO NATURAL CON EQUIPO (A1-RA-I-PP) |  | 1d | 2025-09-11 | 2025-09-11 | A1-I-02_CONFCD, A1-RA-I-02-CONFCR, A1-I-02_CONFNE | 7d | 0d | CAPATAZ - CONSORCIO [0.02 h]; PEON - CONSORCIO [0.16 h]; EXCAVADORA CAT 336 - CONSORCIO [0.16 h]; HERRAMIENTAS MANUALES - CONSORCIO [0.18 h] | 77.91 |
| A1-RA-I-PP-CONFMP |  | A1: CONFORMACIÓN DE CUERPO DE RAMPA CON MATERIAL DE PRESTAMO (A1-RA-I-PP) |  | 1d | 2025-09-12 | 2025-09-12 | A1-RA-I-PP-EXCTN | 7d | 0d | CAPATAZ - CONSORCIO [0.06 h]; OFICIAL - CONSORCIO [0.29 h]; PEON - CONSORCIO [0.29 h]; TRACTOR DE ORUGAS CAT D6D - CONSORCIO [0.29 h]; CAMION CISTERNA (5,000 GLNS.) - CONSORCIO [0.29 h]; HERRAMIENTAS MANUALES - CONSORCIO [0.35 h]; RODILLO LISO VIBRATORIO AUTOPROPULSADO 135HP - CONSORCIO [0.29 h] | 300.72 |
| A1-RA-I-PP-CONFCR |  | A1: CONFORMACIÓN DE CORONA DE RAMPA CON MATERIAL DE PRESTAMO (A1-RA-I-PP) |  | 1d | 2025-09-13 | 2025-09-13 | A1-RA-I-PP-CONFMP | 7d |  | CAPATAZ - CONSORCIO [0.28 h]; OFICIAL - CONSORCIO [1.39 h]; PEON - CONSORCIO [1.39 h]; MOTONIVELADORA 185HP - CONSORCIO [1.39 h]; CAMION CISTERNA (5,000 GLNS.) - CONSORCIO [1.39 h]; HERRAMIENTAS MANUALES - CONSORCIO [1.25 h]; RODILLO LISO VIBRATORIO AUTOPROPULSADO 135HP - CONSORCIO [1.39 h] | 1,306 |
|  | 2 | **RAMPA - (A1-RA-D-PP)** |  |  | 2025-09-21 | 2025-09-23 |  |  |  |  |  |
| A1-RA-D-PP-EXCTN |  | A1: EXCAVACIÓN EN TERRENO NATURAL CON EQUIPO (A1-RA-D-PP) |  | 1d | 2025-09-21 | 2025-09-21 | A1-D-02_CONFCD, A1-RA-I-PP-CONFCR, A1-D-02_CONFNE, OA-TME-05-A1 FF, OA-TME-06-A1 FF | 0d |  | CAPATAZ - CONSORCIO [0.02 h]; PEON - CONSORCIO [0.16 h]; EXCAVADORA CAT 336 - CONSORCIO [0.16 h]; HERRAMIENTAS MANUALES - CONSORCIO [0.18 h] |  |
| A1-RA-D-PP-CONFRMP |  | A1: CONFORMACIÓN DE CUERPO DE RAMPA CON MATERIAL DE PRESTAMO (A1-RA-D-PP) |  | 1d | 2025-09-22 | 2025-09-22 | A1-RA-D-PP-EXCTN | 0d |  | CAPATAZ - CONSORCIO [0.06 h]; OFICIAL - CONSORCIO [0.29 h]; PEON - CONSORCIO [0.29 h]; TRACTOR DE ORUGAS CAT D6D - CONSORCIO [0.29 h]; CAMION CISTERNA (5,000 GLNS.) - CONSORCIO [0.29 h]; HERRAMIENTAS MANUALES - CONSORCIO [0.35 h]; RODILLO LISO VIBRATORIO AUTOPROPULSADO 135HP - CONSORCIO [0.29 h] |  |
| A1-RA-D-PP-CONFCR |  | A1: CONFORMACIÓN DE CORONA DE RAMPA CON MATERIAL DE PRESTAMO (A1-RA-D-PP) |  | 1d | 2025-09-23 | 2025-09-23 | A1-RA-D-PP-CONFRMP, OA-TMG-01-A1 FF, OA-TMG-02-A1 FF | 0d |  | CAPATAZ - CONSORCIO [0.28 h]; OFICIAL - CONSORCIO [1.39 h]; PEON - CONSORCIO [1.39 h]; MOTONIVELADORA 185HP - CONSORCIO [1.39 h]; CAMION CISTERNA (5,000 GLNS.) - CONSORCIO [1.39 h]; HERRAMIENTAS MANUALES - CONSORCIO [1.25 h]; RODILLO LISO VIBRATORIO AUTOPROPULSADO 135HP - CONSORCIO [1.39 h] |  |
|  | 3 | **RAMPA - (A1-RA-I-02)** |  |  | 2025-09-01 | 2025-09-03 |  |  |  |  |  |
| A1-RA-I-02-EXCTN |  | A1: EXCAVACIÓN EN TERRENO NATURAL CON EQUIPO (A1-RA-I-02) |  | 1d | 2025-09-01 | 2025-09-01 | A1-I-01_CONFCD | 14d | 0d | CAPATAZ - CONSORCIO [0.02 h]; PEON - CONSORCIO [0.16 h]; EXCAVADORA CAT 336 - CONSORCIO [0.16 h]; HERRAMIENTAS MANUALES - CONSORCIO [0.18 h] |  |
| A1-RA-I-02-CONFMP |  | A1: CONFORMACIÓN DE CUERPO DE RAMPA CON MATERIAL DE PRESTAMO (A1-RA-I-02) |  | 1d | 2025-09-02 | 2025-09-02 | A1-RA-I-02-EXCTN | 14d | 0d | CAPATAZ - CONSORCIO [0.06 h]; OFICIAL - CONSORCIO [0.29 h]; PEON - CONSORCIO [0.29 h]; TRACTOR DE ORUGAS CAT D6D - CONSORCIO [0.29 h]; CAMION CISTERNA (5,000 GLNS.) - CONSORCIO [0.29 h]; HERRAMIENTAS MANUALES - CONSORCIO [0.35 h]; RODILLO LISO VIBRATORIO AUTOPROPULSADO 135HP - CONSORCIO [0.29 h] |  |
| A1-RA-I-02-CONFCR |  | A1: CONFORMACIÓN DE CORONA DE RAMPA CON MATERIAL DE PRESTAMO (A1-RA-I-02) |  | 1d | 2025-09-03 | 2025-09-03 | A1-RA-I-02-CONFMP | 14d | 7d | CAPATAZ - CONSORCIO [0.28 h]; OFICIAL - CONSORCIO [1.39 h]; PEON - CONSORCIO [1.39 h]; MOTONIVELADORA 185HP - CONSORCIO [1.39 h]; CAMION CISTERNA (5,000 GLNS.) - CONSORCIO [1.39 h]; HERRAMIENTAS MANUALES - CONSORCIO [1.25 h]; RODILLO LISO VIBRATORIO AUTOPROPULSADO 135HP - CONSORCIO [1.39 h] |  |
|  | 04 | **TRANSPORTE DE MATERIAL** |  |  | 2025-07-22 | 2025-09-23 |  |  |  |  |  |
|  | 1 | **SUBPROYECTO A-1** |  |  | 2025-07-22 | 2025-09-23 |  |  |  |  |  |
| OA-TME-05-A1 |  | A1: TRANSPORTE DE MATERIAL EXCEDENTE PARA DISTANCIAS <1KM | level of effort | 62d | 2025-07-22 | 2025-09-21 | A1-D-01_EXC SS, A2-I-02_EXC SS | 0d |  | PEON - CONSORCIO [711.13 h]; CARGADOR SOBRE LLANTAS DE 250HP 4yd3 - CONSORCIO [142.23 h]; PEON VIGIA - CONSORCIO [711.13 h]; CAMION VOLQUETE DE 15 m3 - CONSORCIO [711.13 h] | 267,272 |
| OA-TME-06-A1 |  | A1: TRANSPORTE DE MATERIAL EXCEDENTE PARA DISTANCIAS >1KM | level of effort | 62d | 2025-07-22 | 2025-09-21 | A1-D-01_EXC SS, A2-I-02_EXC | 0d |  | CARGADOR SOBRE LLANTAS DE 250HP 4yd3 - CONSORCIO [465.98 h]; PEON-VIGIA - CONSORCIO [4659.8 h]; CAMION VOLQUETE DE 15 m3 - CONSORCIO [4659.8 h] | 1,488,059.73 |
| OA-TMG-01-A1 |  | A1: TRANSPORTE DE MATERIAL GRANULAR PARA DISTANCIAS <1KM | level of effort | 54d | 2025-08-01 | 2025-09-23 | A1-D-01_PEDR60 SS | 0d |  | PEON - CONSORCIO [294.01 h]; CARGADOR SOBRE LLANTAS DE 250HP 4yd3 - CONSORCIO [58.8 h]; PEON VIGIA - CONSORCIO [294.01 h]; CAMION VOLQUETE DE 15 m3 - CONSORCIO [294.01 h] | 110,500.86 |
| OA-TMG-02-A1 |  | A1: TRANSPORTE DE MATERIAL GRANULAR PARA DISTANCIAS >1KM | level of effort | 54d | 2025-08-01 | 2025-09-23 | A1-D-01_CONFD SS, A1-D-01_PEDR60 SS | 0d |  | CARGADOR SOBRE LLANTAS DE 250HP 4yd3 - CONSORCIO [199.97 h]; PEON-VIGIA - CONSORCIO [1999.73 h]; CAMION VOLQUETE DE 15 m3 - CONSORCIO [1999.73 h] | 638,593.14 |
| OA-TMR-03-A1 |  | A1: TRANSPORTE DE ROCA PARA DISTANCIAS <1KM | level of effort | 44d | 2025-08-04 | 2025-09-16 | A1-D-01_ROCKU SS | 0d |  | PEON - CONSORCIO [129.37 h]; CARGADOR SOBRE LLANTAS DE 250HP 4yd3 - CONSORCIO [25.87 h]; PEON VIGIA - CONSORCIO [129.37 h]; CAMION VOLQUETE DE 15 m3 - CONSORCIO [129.37 h] | 48,623.93 |
| OA-TMR-04-A1 |  | A1: TRANSPORTE DE ROCA PARA DISTANCIAS >1KM | level of effort | 44d | 2025-08-04 | 2025-09-16 | A1-D-01_ROCKU SS | 0d |  | CARGADOR SOBRE LLANTAS DE 250HP 4yd3 - CONSORCIO [36.8 h]; PEON-VIGIA - CONSORCIO [368.01 h]; CAMION VOLQUETE DE 15 m3 - CONSORCIO [368.01 h] | 117,521.09 |
|  | 2 | **SUBPROYECTO A2T1** |  |  | 2025-07-22 | 2025-08-25 |  |  |  |  |  |
| OA-TME-01-A2T1 |  | A2T1: TRANSPORTE DE MATERIAL EXCEDENTE PARA DISTANCIAS <1KM | level of effort | 25d | 2025-07-22 | 2025-08-15 | A2-I-02_EXC SS, A2-D-01_EXC | 25d | 0d | PEON - CONSORCIO [106.36 h]; CARGADOR SOBRE LLANTAS DE 250HP 4yd3 - CONSORCIO [21.27 h]; PEON VIGIA - CONSORCIO [106.36 h]; CAMION VOLQUETE DE 15 m3 - CONSORCIO [106.36 h] | 39,974.57 |
| OA-TME-02-A2T1 |  | A2T1: TRANSPORTE DE MATERIAL EXCEDENTE PARA DISTANCIAS >1KM | level of effort | 25d | 2025-07-22 | 2025-08-15 | A2-I-02_EXC SS, A2-D-01_EXC | 25d | 0d | PEON - CONSORCIO [468.25 h]; CARGADOR SOBRE LLANTAS DE 250HP 4yd3 - CONSORCIO [46.83 h]; CAMION VOLQUETE DE 15 m3 - CONSORCIO [468.25 h] | 149,532.55 |
| OA-TMR-01-A2T1 |  | A2T1: TRANSPORTE DE ROCA PARA DISTANCIAS <1KM | level of effort | 27d | 2025-07-28 | 2025-08-23 | A2-I-02_ROCKU SS, A2-D-01_ROCKU | 20d | 0d | PEON - CONSORCIO; CARGADOR SOBRE LLANTAS DE 250HP 4yd3 - CONSORCIO; PEON VIGIA - CONSORCIO; CAMION VOLQUETE DE 15 m3 - CONSORCIO | 20,992.02 |
| OA-TMR-02-A2T1 |  | A2T1: TRANSPORTE DE ROCA PARA DISTANCIAS >1KM | level of effort | 27d | 2025-07-28 | 2025-08-23 | A2-I-02_ROCKU SS, A2-D-01_ROCKU | 20d | 0d | CARGADOR SOBRE LLANTAS DE 250HP 4yd3 - CONSORCIO [15.22 h]; PEON-VIGIA - CONSORCIO [152.24 h]; CAMION VOLQUETE DE 15 m3 - CONSORCIO [152.24 h] | 48,617.34 |
| OA-TMG-01-A2T1 |  | A2T1: TRANSPORTE DE MATERIAL GRANULAR PARA DISTANCIAS <1KM | level of effort | 28d | 2025-07-29 | 2025-08-25 | A2-I-02_PEDR60 SS | 20d | 0d | PEON - CONSORCIO [306.15 h]; CARGADOR SOBRE LLANTAS DE 250HP 4yd3 - CONSORCIO [61.23 h]; PEON VIGIA - CONSORCIO [306.15 h]; CAMION VOLQUETE DE 15 m3 - CONSORCIO [306.15 h] | 115,065.26 |
| OA-TMG-02-A2T1 |  | A2T1: TRANSPORTE DE MATERIAL GRANULAR PARA DISTANCIAS >1KM | level of effort | 28d | 2025-07-29 | 2025-08-25 | A2-I-02_PEDR60 SS | 20d | 0d | CARGADOR SOBRE LLANTAS DE 250HP 4yd3 - CONSORCIO [75.06 h]; PEON-VIGIA - CONSORCIO [750.58 h]; CAMION VOLQUETE DE 15 m3 - CONSORCIO [750.58 h] | 239,688.66 |

| ID | WBS | Activity | Duration | Start | Finish | Predecessors | Total float | Resources | Cost |
| --- | --- | --- | --- | --- | --- | --- | --- | --- | --- |
|  | T | **PROGRAMA DE CIERRE DE OBRA** |  | 2025-08-04 | 2025-09-23 |  |  |  |  |
| ACOND-DME |  | ACONDICIONAMIENTO DE DEPOSITOS DE MATERIALES EXCEDENTES (DME) | 50d | 2025-08-04 | 2025-09-22 | OA-TME-01-A2T1 SS, OA-TME-02-A2T1 SS, A1-D-01_EXC | 1d | PEON VIGIA - CONSORCIO [325.14 h]; EXCAVADORA CAT 336 - CONSORCIO [48.77 h]; TRACTOR DE ORUGAS CAT D6D - CONSORCIO [325.14 h]; HERRAMIENTAS MANUALES - CONSORCIO [1585.07 h] | 185,004.04 |
| DESMOV |  | DESMOVILIZACIÓN | 5d | 2025-09-19 | 2025-09-23 | ACOND-DME FF, A1-D-01_CONFCD, OA-RELL-A1, OBP-INST-A1, DESCOL-A1, DESV-RIO-A1, MOV-02-A1, TP-TOPO-A1, MOV-01-A1, MOV-01-A1 SS, OA-CONC280-A1, OA-CONC100-A1, OA-EXC-A1, OA-CA-A1, OA-HDP-A1, A2-I-02_CONFNE, RELLE-NO-EST-A2T1, A1-RA-D-PP-CONFCR FF, OBP-MANTVIAL-A1 FF, OBP-INST-A2T1, A2-D-01_CONFNE, SSO-A1 FF, OBP-MANTVIAL-A2T1 | 0d | COSTO - CONSORCIO [9 h] | 46,082.5 |

## Activity codes

| Code | Value | Meaning |
| --- | --- | --- |
| OHLA_ESTRUCTURA OFERTA_A2-T1 | A2-T1-10 | PEDRAPLEN (m3) |
| OHLA_ESTRUCTURA OFERTA_A2-T1 | A2-T1-15 | RELLENO |
| Unidad | M3 | Metros cúbicos |
